# Bureau de projets

Schedule from MS Project, 2000-03-01 to 2000-10-03.

## Calendars

- Standard: Mon-Fri 08:00-12:00, 13:00-17:00; Sat-Sun off.

## Resources

| Resource |
| --- |
| Direction générale |
| Coordinateur de bureau de projets |
| Analyste |
| Développeur |
| Analyste de personnel de bureaux de projets |

## Schedule

| ID | WBS | Task | Type | Duration | Start | Finish | Predecessors | Total slack | Resources | Work |
| --- | --- | --- | --- | --- | --- | --- | --- | --- | --- | --- |
| 1 | 1 | **Bureau de projets** |  | 155d | 2000-03-01 | 2000-10-03 |  | 0d |  | 2308h |
| 2 | 1.1 | **Objectif général** |  | 10d | 2000-03-01 | 2000-03-14 |  | 0d |  | 160h |
| 3 | 1.1.1 | Détermination de l'objectif général du bureau de projets |  | 3d | 2000-03-01 | 2000-03-03 |  | 0d | Direction générale; Coordinateur de bureau de projets | 48h |
| 4 | 1.1.2 | Étude des besoins premiers du bureau de projets (ressources incluses) |  | 2d | 2000-03-06 | 2000-03-07 | 3 | 0d | Direction générale; Coordinateur de bureau de projets | 32h |
| 5 | 1.1.3 | Justification du bureau de projets via un modèle d'entreprise |  | 3d | 2000-03-08 | 2000-03-10 | 4 | 0d | Direction générale; Coordinateur de bureau de projets | 48h |
| 6 | 1.1.4 | Confirmation du financement |  | 2d | 2000-03-13 | 2000-03-14 | 5 | 0d | Direction générale; Coordinateur de bureau de projets | 32h |
| 7 | 1.1.5 | Objectif général achevé | milestone | 0d | 2000-03-14 | 2000-03-14 | 6 | 0d |  |  |
| 8 | 1.2 | **Planification** |  | 66.5d | 2000-03-15 | 2000-06-15 |  | 0d |  | 1192h |
| 9 | 1.2.1 | **Analyse/Logistique** |  | 17d | 2000-03-15 | 2000-04-06 |  | 0d |  | 160h |
| 10 | 1.2.1.1 | Examen des documents sur l'objectif général du bureau de projets |  | 1d | 2000-03-15 | 2000-03-15 | 7 | 0d | Coordinateur de bureau de projets | 8h |
| 11 | 1.2.1.2 | Établissement d'une structure directionnelle |  | 3d | 2000-03-16 | 2000-03-20 | 10 | 0d | Direction générale; Coordinateur de bureau de projets | 48h |
| 12 | 1.2.1.3 | Analyse des objectifs de l'entreprise |  | 2d | 2000-03-21 | 2000-03-22 | 11 | 0d | Coordinateur de bureau de projets | 16h |
| 13 | 1.2.1.4 | Définition de la mission |  | 2d | 2000-03-23 | 2000-03-24 | 12 | 0d | Coordinateur de bureau de projets | 16h |
| 14 | 1.2.1.5 | Définition des objectifs |  | 3d | 2000-03-27 | 2000-03-29 | 13 | 0d | Coordinateur de bureau de projets | 24h |
| 15 | 1.2.1.6 | Établissement du plan de communications |  | 1d | 2000-03-30 | 2000-03-30 | 14 | 0d | Coordinateur de bureau de projets | 8h |
| 16 | 1.2.1.7 | Obtention de l'engagement des ressources principales du bureau de projets |  | 1w | 2000-03-31 | 2000-04-06 | 15 | 0d | Coordinateur de bureau de projets | 40h |
| 17 | 1.2.1.8 | Logistique achevée | milestone | 0d | 2000-04-06 | 2000-04-06 | 16 | 128d |  |  |
| 18 | 1.2.2 | **Polices et procédures** |  | 20d | 2000-04-07 | 2000-05-04 |  | 0d |  | 640h |
| 19 | 1.2.2.1 | Définition des meilleurs processus |  | 1w | 2000-04-07 | 2000-04-13 | 16 | 0d | Coordinateur de bureau de projets; Analyste | 80h |
| 20 | 1.2.2.2 | Définition des meilleurs outils |  | 1w | 2000-04-07 | 2000-04-13 | 16 | 0d | Coordinateur de bureau de projets; Analyste | 80h |
| 21 | 1.2.2.3 | Définition des meilleures techniques |  | 1w | 2000-04-07 | 2000-04-13 | 16 | 0d | Coordinateur de bureau de projets; Analyste | 80h |
| 22 | 1.2.2.4 | Établissement des relations entre ressources |  | 1w | 2000-04-07 | 2000-04-13 | 16 | 0d | Coordinateur de bureau de projets; Analyste | 80h |
| 23 | 1.2.2.5 | Définition des critères de conformité |  | 1w | 2000-04-07 | 2000-04-13 | 16 | 0d | Coordinateur de bureau de projets; Analyste | 80h |
| 24 | 1.2.2.6 | Définition des processus de test de projet |  | 1w | 2000-04-14 | 2000-04-20 | 19, 20, 21, 23, 22 | 0d | Coordinateur de bureau de projets; Analyste | 80h |
| 25 | 1.2.2.7 | Définition des besoins de rapports |  | 1w | 2000-04-21 | 2000-04-27 | 24 | 0d | Coordinateur de bureau de projets; Analyste | 80h |
| 26 | 1.2.2.8 | Définition des priorités du bureau de projets |  | 1w | 2000-04-28 | 2000-05-04 | 25 | 0d | Coordinateur de bureau de projets; Analyste | 80h |
| 27 | 1.2.2.9 | Polices et procédures achevées | milestone | 0d | 2000-05-04 | 2000-05-04 | 26 | 0d |  |  |

| ID | WBS | Task | Type | Duration | Start | Finish | Predecessors | Total slack | Free slack | Resources | Work |
| --- | --- | --- | --- | --- | --- | --- | --- | --- | --- | --- | --- |
| 28 | 1.2.3 | **Normes et contrôles de projet** |  | 28d | 2000-05-05 | 2000-06-13 |  | 0d |  |  | 368h |
| 29 | 1.2.3.1 | Définitions sécurité/rôles/responsabilités |  | 3d | 2000-05-05 | 2000-05-09 | 27 | 0d |  | Coordinateur de bureau de projets; Analyste | 48h |
| 30 | 1.2.3.2 | Définition des paramètres de système |  | 5d | 2000-05-10 | 2000-05-16 | 29 | 0d |  | Coordinateur de bureau de projets; Analyste | 80h |
| 31 | 1.2.3.3 | Création du schéma numéroté du projet |  | 2d | 2000-05-17 | 2000-05-18 | 30 | 0d |  | Coordinateur de bureau de projets; Analyste | 32h |
| 32 | 1.2.3.4 | Définition de l'intégration des rapports financiers |  | 1w | 2000-05-19 | 2000-05-25 | 31 | 0d |  | Coordinateur de bureau de projets; Analyste | 80h |
| 33 | 1.2.3.5 | Identification des catégories du projet pour la création de modèles |  | 3d | 2000-05-26 | 2000-05-30 | 32 | 0d |  | Coordinateur de bureau de projets; Analyste | 48h |
| 34 | 1.2.3.6 | Création des modèles de projets |  | 2w | 2000-05-31 | 2000-06-13 | 33 | 0d |  | Développeur | 80h |
| 35 | 1.2.3.7 | Normes et contrôles de projet achevés | milestone | 0d | 2000-06-13 | 2000-06-13 | 34 | 0d |  |  |  |
| 36 | 1.2.4 | Prise de direction du bureau de projets |  | 1d | 2000-06-14 | 2000-06-14 | 35 | 0d |  | Direction générale; Coordinateur de bureau de projets | 16h |
| 37 | 1.2.5 | Annonce du bureau de projets |  | 4h | 2000-06-15 | 2000-06-15 | 36 | 0d |  | Direction générale; Coordinateur de bureau de projets | 8h |
| 38 | 1.2.6 | Planification achevée | milestone | 0d | 2000-06-15 | 2000-06-15 | 37 | 0d |  |  |  |
| 39 | 1.3 | **Lancement du bureau de projets** |  | 27d | 2000-06-15 | 2000-07-24 |  | 0d |  |  | 400h |
| 40 | 1.3.1 | Embauche du personnel du bureau de projets |  | 1w | 2000-06-15 | 2000-06-22 | 38 | 11d | 0d | Coordinateur de bureau de projets | 40h |
| 41 | 1.3.2 | **Support du bureau de projets pour les projets existants** |  | 11d | 2000-06-22 | 2000-07-07 |  | 11d |  |  | 104h |
| 42 | 1.3.2.1 | Détermination des projets existants |  | 2d | 2000-06-22 | 2000-06-26 | 40 | 11d | 0d | Coordinateur de bureau de projets; Analyste de personnel de bureaux de projets | 32h |
| 43 | 1.3.2.2 | Audit des projets |  | 1w | 2000-06-26 | 2000-07-03 | 42 | 11d | 0d | Analyste de personnel de bureaux de projets | 40h |
| 44 | 1.3.2.3 | Modification des projets pour raisons de conformité |  | 3d | 2000-07-03 | 2000-07-06 | 43 | 11d | 0d | Analyste de personnel de bureaux de projets | 24h |
| 45 | 1.3.2.4 | Entrée des projets sous la direction du bureau de projets |  | 1d | 2000-07-06 | 2000-07-07 | 44 | 11d | 0d | Analyste de personnel de bureaux de projets | 8h |
| 46 | 1.3.2.5 | Support du bureau de projets pour les projets existants achevé | milestone | 0d | 2000-07-07 | 2000-07-07 | 45 | 11d |  |  |  |
| 47 | 1.3.3 | **Support du bureau de projets pour les nouveaux projets** |  | 27d | 2000-06-15 | 2000-07-24 |  | 0d |  |  | 256h |
| 48 | 1.3.3.1 | Identification des nouveaux projets |  | 1w | 2000-06-15 | 2000-06-22 | 38 | 0d |  | Coordinateur de bureau de projets; Analyste de personnel de bureaux de projets | 80h |
| 49 | 1.3.3.2 | Création de projets grâce aux critères/modèles du bureau de projets |  | 2w | 2000-06-22 | 2000-07-06 | 48 | 0d |  | Analyste de personnel de bureaux de projets | 80h |
| 50 | 1.3.3.3 | Établissement de critères de contrôle |  | 3d | 2000-07-06 | 2000-07-11 | 49 | 0d |  | Analyste de personnel de bureaux de projets | 24h |
| 51 | 1.3.3.4 | Établissement de statistiques de performances |  | 4d | 2000-07-11 | 2000-07-17 | 50 | 0d |  | Analyste de personnel de bureaux de projets | 32h |
| 52 | 1.3.3.5 | Établissement de lignes budgétaires directrices |  | 3d | 2000-07-17 | 2000-07-20 | 51 | 0d |  | Analyste de personnel de bureaux de projets | 24h |
| 53 | 1.3.3.6 | Entrée des projets sous la direction du bureau de projets |  | 2d | 2000-07-20 | 2000-07-24 | 52 | 0d |  | Analyste de personnel de bureaux de projets | 16h |
| 54 | 1.3.3.7 | Support du bureau de projets pour les nouveaux projets achevé | milestone | 0d | 2000-07-24 | 2000-07-24 | 53 | 0d |  |  |  |
| 55 | 1.3.4 | Lancement du bureau de projets achevé | milestone | 0d | 2000-07-24 | 2000-07-24 | 54, 46 | 0d |  |  |  |

| ID | WBS | Task | Type | Duration | Start | Finish | Predecessors | Total slack | Resources | Work |
| --- | --- | --- | --- | --- | --- | --- | --- | --- | --- | --- |
| 56 | 1.4 | **Gestion (tout au long du projet)** |  | 25.5d | 2000-07-24 | 2000-08-28 |  | 0d |  | 204h |
| 57 | 1.4.1 | Examen des priorités de l'entreprise applicables aux projets |  | 1w | 2000-07-24 | 2000-07-31 | 55 | 0d | Analyste de personnel de bureaux de projets | 40h |
| 58 | 1.4.2 | **Estimation des risques** |  | 9d | 2000-07-31 | 2000-08-11 |  | 0d |  | 72h |
| 59 | 1.4.2.1 | Estimation des risques |  | 1w | 2000-07-31 | 2000-08-07 | 57 | 0d | Analyste de personnel de bureaux de projets | 40h |
| 60 | 1.4.2.2 | Estimation des risques par rapport aux priorités du projet |  | 3d | 2000-08-07 | 2000-08-10 | 59 | 0d | Analyste de personnel de bureaux de projets | 24h |
| 61 | 1.4.2.3 | Préparation des plans d'imprévus |  | 1d | 2000-08-10 | 2000-08-11 | 60 | 0d | Analyste de personnel de bureaux de projets | 8h |
| 62 | 1.4.2.4 | Estimation des risques achevée | milestone | 0d | 2000-08-11 | 2000-08-11 | 61 | 0d |  |  |
| 63 | 1.4.3 | **Supervision** |  | 11.5d | 2000-08-11 | 2000-08-28 |  | 0d |  | 92h |
| 64 | 1.4.3.1 | Préparation de l'agenda des réunions d'examen de projet |  | 1d | 2000-08-11 | 2000-08-14 | 62 | 0d | Analyste de personnel de bureaux de projets | 8h |
| 65 | 1.4.3.2 | Réunions d'examen de projet |  | 4h | 2000-08-14 | 2000-08-14 | 64 | 0d | Analyste de personnel de bureaux de projets | 4h |
| 66 | 1.4.3.3 | Création de rapports sur les questions critiques, les budgets, les affectations de ressources, les suivis de progression, etc. |  | 2d | 2000-08-15 | 2000-08-16 | 65 | 0d | Analyste de personnel de bureaux de projets | 16h |
| 67 | 1.4.3.4 | Travail d'allègement des questions critiques |  | 2d | 2000-08-17 | 2000-08-18 | 66 | 0d | Analyste de personnel de bureaux de projets | 16h |
| 68 | 1.4.3.5 | Assistance à l'affectation de ressources |  | 2d | 2000-08-21 | 2000-08-22 | 67 | 0d | Analyste de personnel de bureaux de projets | 16h |
| 69 | 1.4.3.6 | Gel/annonce des lignes de base du projet |  | 2d | 2000-08-23 | 2000-08-24 | 68 | 0d | Analyste de personnel de bureaux de projets | 16h |
| 70 | 1.4.3.7 | Établissement d'un contrôle en cas de changement de direction |  | 1d | 2000-08-25 | 2000-08-25 | 69 | 0d | Analyste de personnel de bureaux de projets | 8h |
| 71 | 1.4.3.8 | Gel/annonce des budgets du projet |  | 1d | 2000-08-28 | 2000-08-28 | 70 | 0d | Analyste de personnel de bureaux de projets | 8h |
| 72 | 1.4.3.9 | Supervision achevée | milestone | 0d | 2000-08-28 | 2000-08-28 | 71 | 0d |  |  |
| 73 | 1.5 | **Historique/Archives** |  | 13d | 2000-08-29 | 2000-09-14 |  | 0d |  | 144h |
| 74 | 1.5.1 | Établissement des archives du projet |  | 1w | 2000-08-29 | 2000-09-04 | 72 | 0d | Coordinateur de bureau de projets; Analyste de personnel de bureaux de projets | 80h |
| 75 | 1.5.2 | Établissement de la liste de leçons reçues |  | 1w | 2000-09-05 | 2000-09-11 | 74 | 0d | Analyste de personnel de bureaux de projets | 40h |
| 76 | 1.5.3 | Gestion des archives du projet |  | 3d | 2000-09-12 | 2000-09-14 | 75 | 0d | Analyste de personnel de bureaux de projets | 24h |
| 77 | 1.5.4 | Historique achevée | milestone | 0d | 2000-09-14 | 2000-09-14 | 76 | 0d |  |  |
| 78 | 1.6 | **Examen post-exécution** |  | 13d | 2000-09-15 | 2000-10-03 |  | 0d |  | 208h |
| 79 | 1.6.1 | Obtention des commentaires des utilisateurs |  | 3d | 2000-09-15 | 2000-09-19 | 77 | 0d | Coordinateur de bureau de projets; Analyste de personnel de bureaux de projets | 48h |
| 80 | 1.6.2 | Évaluation des leçons reçues |  | 1w | 2000-09-20 | 2000-09-26 | 79 | 0d | Coordinateur de bureau de projets; Analyste de personnel de bureaux de projets | 80h |
| 81 | 1.6.3 | Modification des éléments si nécessaire |  | 1w | 2000-09-27 | 2000-10-03 | 80 | 0d | Coordinateur de bureau de projets; Analyste de personnel de bureaux de projets | 80h |
| 82 | 1.6.4 | Examen post-exécution achevé | milestone | 0d | 2000-10-03 | 2000-10-03 | 81 | 0d |  |  |
| 83 | 1.7 | Modèle de Bureau de projet achevé | milestone | 0d | 2000-10-03 | 2000-10-03 | 82 | 0d |  |  |
